Schedule from GanttProject, 2026-01-07 to 2026-03-06.

## Calendars

- Project calendar: Mon-Fri working; Sat-Sun off.

## Resources

| Resource | Group | Rate |
| --- | --- | --- |
| Boss |  |  |
| Kurt Schluss | Mechatroniker |  |
| Joe Fisi | Entwickler |  |
| Klara M. | Assistenz |  |
| Lieferant 1 | Extern |  |
| Lieferant 2 | Extern |  |
| Liererant 3 | Extern |  |
| Hardware | Material | 40000 |
| Software | Material | 12000 |

## Schedule

| ID | WBS | Task | Type | Duration | Start | Finish | Predecessors | Resources |
| --- | --- | --- | --- | --- | --- | --- | --- | --- |
| 1 | 1 | **IT-Infrastruktur-Projekt** |  | 42d | 2026-01-07 | 2026-03-05 |  |  |
| 2 | 1.1 | Start | milestone | 0d | 2026-01-07 | 2026-01-07 |  |  |
| 3 | 1.2 | **Planung** |  | 10d | 2026-01-07 | 2026-01-20 |  |  |
| 4 | 1.2.1 | Grobplanung |  | 2d | 2026-01-07 | 2026-01-08 | 2 | Boss |
| 5 | 1.2.2 | Materialliste |  | 1d | 2026-01-09 | 2026-01-09 | 4 | Kurt Schluss |
| 6 | 1.2.3 | Geräteliste |  | 1d | 2026-01-12 | 2026-01-12 | 4, 5 | Joe Fisi |
| 7 | 1.2.4 | Softwareliste |  | 1d | 2026-01-09 | 2026-01-09 | 4 | Joe Fisi |
| 8 | 1.2.5 | Preise/Lieferanten |  | 1d | 2026-01-09 | 2026-01-09 | 4 | Klara M. |
| 9 | 1.2.6 | Pläne anfertigen |  | 5d | 2026-01-13 | 2026-01-19 | 4, 6 | Boss; Kurt Schluss |
| 10 | 1.2.7 | Bestellungen aufgeben |  | 1d | 2026-01-20 | 2026-01-20 | 9 | Klara M.; Hardware; Software |
| 11 | 1.3 | **Vorarbeiten** |  | 9d | 2026-01-28 | 2026-02-09 |  |  |
| 12 | 1.3.1 | Kabel + Kanäle anliefern |  | 1d | 2026-01-28 | 2026-01-28 | 6, 7, 8, 9, 10FS+5d | Kurt Schluss; Lieferant 1 |
| 13 | 1.3.2 | Kabelkanäle anbringen |  | 1d | 2026-01-29 | 2026-01-29 | 12 | Kurt Schluss |
| 14 | 1.3.3 | Verkabelung durchführen EG |  | 3d | 2026-01-30 | 2026-02-03 | 12, 13 | Kurt Schluss |
| 15 | 1.3.4 | Verkabelung durchführen OG |  | 4d | 2026-02-04 | 2026-02-09 | 14 | Kurt Schluss |
| 16 | 1.4 | **IT-Infrastruktur** |  | 16d | 2026-02-10 | 2026-03-03 |  |  |
| 17 | 1.4.1 | **Anlieferungen** |  | 5d | 2026-02-10 | 2026-02-16 |  |  |
| 18 | 1.4.1.1 | Server anliefern |  | 1d | 2026-02-10 | 2026-02-10 | 15 | Boss [10%]; Joe Fisi; Lieferant 2 |
| 19 | 1.4.1.2 | Serverschrank anliefern |  | 1d | 2026-02-11 | 2026-02-11 | 18 | Joe Fisi; Lieferant 2 |
| 20 | 1.4.1.3 | Drucker anliefern |  | 1d | 2026-02-12 | 2026-02-12 | 19 | Kurt Schluss; Liererant 3 |
| 21 | 1.4.1.4 | PCs anliefern |  | 1d | 2026-02-13 | 2026-02-13 | 20 | Joe Fisi; Liererant 3 |
| 22 | 1.4.1.5 | Switche anliefern |  | 1d | 2026-02-16 | 2026-02-16 | 21 | Joe Fisi; Liererant 3 |
| 23 | 1.4.2 | **IT-Struktur fertigstellen** |  | 8d | 2026-02-17 | 2026-02-26 |  |  |
| 24 | 1.4.2.1 | Geräte aufstellen |  | 1d | 2026-02-17 | 2026-02-17 | 22 | Kurt Schluss; Joe Fisi |
| 25 | 1.4.2.2 | Geräte anschliessen |  | 2d | 2026-02-18 | 2026-02-19 | 24 | Kurt Schluss |
| 26 | 1.4.2.3 | Geräte konfigurieren |  | 5d | 2026-02-20 | 2026-02-26 | 22, 25 | Joe Fisi |
| 27 | 1.4.2.4 | VLANs einrichten |  | 1d | 2026-02-20 | 2026-02-20 | 25 | Boss |

| ID | WBS | Task | Type | Duration | Start | Finish | Predecessors | Resources |
| --- | --- | --- | --- | --- | --- | --- | --- | --- |
| 28 | 1.4.3 | **Tests durchführen** |  | 3d | 2026-02-27 | 2026-03-03 |  |  |
| 29 | 1.4.3.1 | Konnektivität prüfen |  | 1d | 2026-02-27 | 2026-02-27 | 26, 27 | Kurt Schluss |
| 30 | 1.4.3.2 | Zugriffsrechte prüfen |  | 1d | 2026-03-02 | 2026-03-02 | 29 | Joe Fisi |
| 31 | 1.4.3.3 | Softwarefunktionalität prüfen |  | 1d | 2026-03-03 | 2026-03-03 | 30 | Joe Fisi |
| 32 | 1.5 | **Abschluss** |  | 2d | 2026-03-04 | 2026-03-05 |  |  |
| 33 | 1.5.1 | Dokumentation übergeben |  | 1d | 2026-03-04 | 2026-03-04 | 31 | Boss |
| 34 | 1.5.2 | Bedienungs-Einweisung |  | 1d | 2026-03-05 | 2026-03-05 | 33 | Boss |
| 35 | 1.5.3 | Ende | milestone | 0d | 2026-03-06 | 2026-03-06 | 34 |  |
